# Presa de Relaves Tambomayo 140505

Schedule from MS Project, 2022-08-01 to 2023-05-27, status date 2020-07-01, 10 hours a day, costs in S..

## Calendars

- QUELLAVECO: Mon-Sun 07:00-12:00, 13:00-18:00.

## Resources

| Resource |
| --- |
| Rellenos dique |
| Enrocado |
| Excavaciones |
| Horas Hombre |

## Schedule

| ID | WBS | Task | Type | Duration | Start | Finish | Predecessors | Baseline start | Baseline finish | Baseline duration | Total slack | Free slack | Resources | Work | Cost | Baseline cost | Días Calendario | Frente |
| --- | --- | --- | --- | --- | --- | --- | --- | --- | --- | --- | --- | --- | --- | --- | --- | --- | --- | --- |
| 1 | 1 | **DEFENSAS RIBEREÑAS SECTOR SECHIN TRAMO 1Y2** |  | 300d | 2022-08-01 | 2023-05-27 |  |  |  |  | 0d |  |  | 441107h | 392,754.5 |  | 300 d |  |
| 2 | 1.1 | **HITOS** |  | 300d | 2022-08-01 | 2023-05-27 |  |  |  |  | 0d |  |  |  |  |  | 300 d |  |
| 3 | 1.1.1 | INICIO CONTRACTUAL - ADJUDICACION | milestone | 0d | 2022-08-01 | 2022-08-01 |  | 2020-06-05 | 2020-06-11 | 7d | 0d |  |  |  |  |  | 0 d |  |
| 4 | 1.1.2 | FIN DE PROYECTO | milestone | 0d | 2023-05-27 | 2023-05-27 | 171 | 2020-06-05 | 2020-06-11 | 7d | 0d |  |  |  |  |  | 0 d |  |
| 5 | 1.2 | **ACTIVIDADES PRE-CONSTRUCCION** |  | 35d | 2022-08-01 | 2022-09-04 |  |  |  |  | 0d |  |  |  | 392,754.5 |  | 35 d |  |
| 6 | 1.2.1 | **LEGAL** |  | 7d | 2022-08-01 | 2022-08-07 |  | 2020-06-05 | 2020-06-11 | 7d | 0d |  |  |  |  |  | 7 d |  |
| 7 | 1.2.1.1 | REVISIÓN DE CONTRATO Y ANEXOS |  | 7d | 2022-08-01 | 2022-08-07 | 3 | 2020-06-05 | 2020-06-11 | 7d | 0d |  |  |  |  |  | 7 d |  |
| 8 | 1.2.2 | **PLANES DE GESTION** |  | 7d | 2022-08-01 | 2022-08-07 |  | 2020-06-05 | 2020-06-11 | 7d | 0d |  |  |  |  |  | 7 d |  |
| 9 | 1.2.2.1 | ELABORACIÓN PLANES DE GESTIÓN |  | 7d | 2022-08-01 | 2022-08-07 | 7SS | 2020-06-05 | 2020-06-11 | 7d | 0d |  |  |  |  |  | 7 d |  |
| 10 | 1.2.2.2 | APROBACIÓN DE PLANES DE GESTIÓN |  | 7d | 2022-08-01 | 2022-08-07 | 7SS | 2020-06-05 | 2020-06-11 | 7d | 0d |  |  |  |  |  | 7 d |  |
| 11 | 1.2.3 | **GESTIÓN DEL PERSONAL** |  | 35d | 2022-08-01 | 2022-09-04 |  | 2020-06-05 | 2020-06-23 | 19d | 0d |  |  |  |  |  | 35 d |  |
| 12 | 1.2.3.1 | RECLUTAMIENTO PERSONAL EMPLEADO |  | 7d | 2022-08-01 | 2022-08-07 | 7SS, 9SS, 10SS | 2020-06-05 | 2020-06-09 | 5d | 0d |  |  |  |  |  | 7 d |  |
| 13 | 1.2.3.2 | RECLUTAMIENTO PERSONAL OBRERO |  | 7d | 2022-08-04 | 2022-08-10 | 12SS+3d | 2020-06-05 | 2020-06-09 | 5d | 0d |  |  |  |  |  | 7 d |  |
| 14 | 1.2.3.3 | EXÁMENES MÉDICOS |  | 7d | 2022-08-08 | 2022-08-14 | 12SS+4d, 13SS+4d | 2020-06-09 | 2020-06-13 | 5d | 0d |  |  |  |  |  | 7 d |  |
| 15 | 1.2.3.4 | INDUCCIÓN EN OBRA |  | 7d | 2022-08-15 | 2022-08-21 | 14 | 2020-06-14 | 2020-06-17 | 4d | 0d |  |  |  |  |  | 7 d |  |
| 16 | 1.2.3.5 | AUTORIZACIÓN DE FOTOCHECK |  | 7d | 2022-08-22 | 2022-08-28 | 15 | 2020-06-18 | 2020-06-20 | 3d | 0d |  |  |  |  |  | 7 d |  |
| 17 | 1.2.3.6 | CERTIFICACIÓN DE OPERADORES |  | 7d | 2022-08-29 | 2022-09-04 | 16 | 2020-06-21 | 2020-06-23 | 3d | 0d |  |  |  |  |  | 7 d |  |
| 18 | 1.2.4 | **GESTIÓN DE EQUIPOS** |  | 35d | 2022-08-01 | 2022-09-04 |  | 2020-06-05 | 2020-06-28 | 24d | 0d |  |  |  | 392,754.5 | 392,754.5 | 35 d |  |
| 19 | 1.2.4.1 | O/C ALQUILER DE EQUIPOS |  | 8d | 2022-08-01 | 2022-08-08 | 9SS, 3SS | 2020-06-05 | 2020-06-09 | 5d | 0d |  |  |  |  |  | 8 d |  |
| 20 | 1.2.4.2 | REVISIÓN TÉCNICA |  | 7d | 2022-08-09 | 2022-08-15 | 19 | 2020-06-10 | 2020-06-16 | 7d | 0d |  |  |  |  |  | 7 d |  |
| 21 | 1.2.4.3 | APROBACIÓN DE EQUIPOS |  | 8d | 2022-08-16 | 2022-08-23 | 20 | 2020-06-17 | 2020-06-21 | 5d | 0d |  |  |  |  |  | 8 d |  |
| 22 | 1.2.4.4 | MOVILIZACIÓN DE EQUIPOS |  | 12d | 2022-08-24 | 2022-09-04 | 21 | 2020-06-22 | 2020-06-28 | 7d | 0d |  |  |  | 392,754.5 | 392,754.5 | 12 d |  |
| 23 | 1.3 | **ACTIVIDADES CONSTRUCCIÓN** |  | 245d | 2022-09-05 | 2023-05-07 |  |  |  |  | 0d |  |  | 441107h |  |  | 245 d |  |
| 24 | 1.3.1 | **PRELIMINARES** |  | 245d | 2022-09-05 | 2023-05-07 |  |  |  |  | 0d |  |  | 91174.2h |  |  | 245 d |  |
| 25 | 1.3.1.1 | INSTALACION DE FACILIDADES |  | 5d | 2022-09-05 | 2022-09-09 | 17, 22 |  |  |  | 0d |  |  |  |  |  | 5 d |  |
| 26 | 1.3.1.2 | TRAZO Y REPLANTEO PRELIMINAR |  | 5d | 2022-09-05 | 2022-09-09 | 25SS |  |  |  | 0d |  | Horas Hombre | 1393.8h |  |  | 5 d | Km |
| 27 | 1.3.1.3 | CONTROL TOPOGRAFICO DURANTE LA EJECUCION |  | 240d | 2022-09-10 | 2023-05-07 | 26 |  |  |  | 20d |  | Horas Hombre | 30030h |  |  | 240 d | mes |
| 28 | 1.3.1.4 | HABILITACION DE ACCESOS |  | 20d | 2022-09-10 | 2022-09-29 | 26 |  |  |  | 0d |  | Horas Hombre | 3010.33h |  |  | 20 d | km |
| 29 | 1.3.1.5 | DESVIO Y MANEJO DE AGUAS SUPERFICIALES |  | 20d | 2022-09-10 | 2022-09-29 | 28SS |  |  |  | 0d |  | Horas Hombre | 1422.04h |  |  | 20 d | m3 |
| 30 | 1.3.1.6 | MANTENIMIENTO DE VIAS Y SEGURIDAD VIAL |  | 220d | 2022-09-30 | 2023-05-07 | 29 |  |  |  | 20d | 0d | Horas Hombre | 19018h |  |  | 220 d | mes |
| 31 | 1.3.1.7 | PLAN DE MANEJO AMBIENTAL |  | 220d | 2022-09-30 | 2023-05-07 | 30SS |  |  |  | 20d |  | Horas Hombre | 36300h |  |  | 220 d | mes |

| ID | WBS | Task | Duration | Start | Finish | Predecessors | Total slack | Free slack | Resources | Work | Días Calendario | Frente |
| --- | --- | --- | --- | --- | --- | --- | --- | --- | --- | --- | --- | --- |
| 32 | 1.3.2 | **OPERACIÓN Y EXPLOTACION DE MATERIAL** | 220d | 2022-09-30 | 2023-05-07 |  | 20d |  |  | 20129.1h | 220 d |  |
| 33 | 1.3.2.1 | EXPLOTACION Y PREPARACION DE MATERIAL PARA CONFORMACION DE DIQUE | 220d | 2022-09-30 | 2023-05-07 | 29 | 20d | 0d | Horas Hombre | 1784.12h | 220 d | m3 |
| 34 | 1.3.2.2 | EXPLOTACION Y PREPARACION DE MATERIAL PARA AFIRMADO EN CORONA | 220d | 2022-09-30 | 2023-05-07 | 33SS | 20d | 0d | Horas Hombre | 3065.92h | 220 d | m3 |
| 35 | 1.3.2.3 | PREPARACIÓN DE MATERIAL PARA CONFORMACIÓN DE DIQUE | 220d | 2022-09-30 | 2023-05-07 | 34SS | 20d | 0d | Horas Hombre | 15279.1h | 220 d | m3 |
| 36 | 1.3.3 | **CONSTRUCCION DE DEFENSAS RIBEREÑAS** | 220d | 2022-09-30 | 2023-05-07 |  | 0d |  |  | 233406h | 220 d |  |
| 37 | 1.3.3.1 | **Frente 01** | 194d | 2022-09-30 | 2023-04-11 |  | 26d |  |  | 81021.7h | 194 d |  |
| 38 | 1.3.3.1.1 | **DIPR-20 MD (24+400-20+750) L=2.93km** | 121d | 2022-09-30 | 2023-01-28 |  | 26d |  |  | 17893.2h | 121 d |  |
| 39 | 1.3.3.1.1.1 | **EXCAVACIONES** | 33d | 2022-09-30 | 2022-11-01 |  | 26d |  |  | 5006.71h | 33 d |  |
| 40 | 1.3.3.1.1.1.1 | EXCAVACION EN MATERIAL SUELTO | 16d | 2022-09-30 | 2022-10-15 | 29 | 26d | 0d | Excavaciones [703300%]; Horas Hombre | 481.83h | 16 d | m3 |
| 41 | 1.3.3.1.1.1.2 | EXCAVACION DE UÑA CON NIVEL FREATICO | 33d | 2022-09-30 | 2022-11-01 | 40SS | 26d | 0d | Excavaciones; Horas Hombre | 2450.89h | 33 d | m3 |
| 42 | 1.3.3.1.1.1.3 | PERFILADO DE TALUD + FUNDACION | 33d | 2022-09-30 | 2022-11-01 | 41SS | 26d | 0d | Horas Hombre | 1041.31h | 33 d | m2 |
| 43 | 1.3.3.1.1.1.4 | CONFORMACION DE DME/DMO | 33d | 2022-09-30 | 2022-11-01 | 42SS | 207d |  | Horas Hombre | 1032.68h | 33 d | m3 |
| 44 | 1.3.3.1.1.2 | **RELLENOS EN DIQUE** | 116d | 2022-10-05 | 2023-01-28 |  | 36d |  |  | 12886.5h | 116 d |  |
| 45 | 1.3.3.1.1.2.1 | CONFORMACION Y COMPACTACION DEL DIQUE | 35d | 2022-10-05 | 2022-11-08 | 41SS+5d | 193d | 0d | Rellenos dique [354100%]; Horas Hombre | 512.08h | 35 d | m3 |
| 46 | 1.3.3.1.1.2.2 | INSTALACION DE GEOTEXTIL | 35d | 2022-10-12 | 2022-11-15 | 45SS+7d | 193d |  | Horas Hombre | 4932.16h | 35 d | m2 |
| 47 | 1.3.3.1.1.2.3 | ENROCADO - UÑA | 41d | 2022-10-15 | 2022-11-24 | 42SS+15d | 26d | 0d | Enrocado; Horas Hombre | 2201.92h | 41 d | m3 |
| 48 | 1.3.3.1.1.2.4 | ENROCADO - TALUD | 86d | 2022-10-25 | 2023-01-18 | 47SS+10d | 119d | 0d | Enrocado; Horas Hombre | 4180.32h | 86 d | m3 |
| 49 | 1.3.3.1.1.2.5 | RELLENO CON MATERIAL PROPIO - UÑA | 21d | 2023-01-08 | 2023-01-28 | 48SS+75d | 119d | 0d | Rellenos dique [350400%]; Horas Hombre | 523.5h | 21 d | m3 |
| 50 | 1.3.3.1.1.2.6 | RELLENO CON MATERIAL AFIRMADO - CORONA | 21d | 2023-01-08 | 2023-01-28 | 49SS | 119d |  | Rellenos dique [139400%]; Horas Hombre | 536.55h | 21 d | m3 |
| 51 | 1.3.3.1.2 | **DIPR-18 MD (19+500 -16+300) L=3.17km** | 136d | 2022-10-16 | 2023-02-28 |  | 66d |  |  | 26642.4h | 136 d |  |
| 52 | 1.3.3.1.2.1 | **EXCAVACIONES** | 68d | 2022-10-16 | 2022-12-22 |  | 117d |  |  | 11508.9h | 68 d |  |
| 53 | 1.3.3.1.2.1.1 | LIMPIEZA Y DESBROCE | 40d | 2022-10-16 | 2022-11-24 | 40 | 137d | 0d | Horas Hombre | 268h | 40 d | Ha |
| 54 | 1.3.3.1.2.1.2 | EXCAVACION EN MATERIAL SUELTO | 40d | 2022-10-16 | 2022-11-24 | 53SS | 137d | 0d | Excavaciones; Horas Hombre | 1046.89h | 40 d | m3 |
| 55 | 1.3.3.1.2.1.3 | EXCAVACION EN ROCA SUELTA | 51d | 2022-11-02 | 2022-12-22 | 41 | 100d | 0d | Excavaciones [87200%]; Horas Hombre | 502.22h | 51 d | m3 |
| 56 | 1.3.3.1.2.1.4 | EXCAVACION EN ROCA FIJA | 51d | 2022-11-02 | 2022-12-22 | 55SS | 100d | 0d | Excavaciones [25130%]; Horas Hombre | 288.97h | 51 d | m3 |
| 57 | 1.3.3.1.2.1.5 | EXCAVACION DE UÑA CON NIVEL FREATICO | 51d | 2022-11-02 | 2022-12-22 | 56SS | 100d | 0d | Excavaciones; Horas Hombre | 3733.96h | 51 d | m3 |
| 58 | 1.3.3.1.2.1.6 | MEJORAMIENTO DE SUELO DE FUNDACION | 51d | 2022-11-02 | 2022-12-22 | 57SS | 156d | 0d | Horas Hombre | 1403.56h | 51 d |  |
| 59 | 1.3.3.1.2.1.7 | PERFILADO DE TALUD + FUNDACION | 51d | 2022-11-02 | 2022-12-22 | 58SS | 156d | 0d | Horas Hombre | 1789.19h | 51 d | m2 |
| 60 | 1.3.3.1.2.1.8 | DESCOLMATACION DEL CAUCE | 51d | 2022-11-02 | 2022-12-22 | 59SS | 156d | 0d | Horas Hombre | 694.03h | 51 d | m3 |
| 61 | 1.3.3.1.2.1.9 | CONFORMACION DE DME/DMO | 51d | 2022-11-02 | 2022-12-22 | 60SS | 156d |  | Horas Hombre | 1782.04h | 51 d | m3 |

| ID | WBS | Task | Duration | Start | Finish | Predecessors | Total slack | Free slack | Resources | Work | Días Calendario | Frente |
| --- | --- | --- | --- | --- | --- | --- | --- | --- | --- | --- | --- | --- |
| 62 | 1.3.3.1.2.2 | **RELLENOS EN DIQUE** | 112d | 2022-11-09 | 2023-02-28 |  | 42d |  |  | 15133.5h | 112 d |  |
| 63 | 1.3.3.1.2.2.1 | CONFORMACION Y COMPACTACION DEL DIQUE | 51d | 2022-11-09 | 2022-12-29 | 57SS+7d | 142d | 0d | Rellenos dique [958700%]; Horas Hombre | 1386.42h | 51 d | m3 |
| 64 | 1.3.3.1.2.2.2 | INSTALACION DE GEOTEXTIL | 51d | 2022-11-16 | 2023-01-05 | 63SS+7d | 142d |  | Horas Hombre | 6070.75h | 51 d | m2 |
| 65 | 1.3.3.1.2.2.3 | ENROCADO - UÑA | 55d | 2022-11-25 | 2023-01-18 | 47 | 26d | 0d | Enrocado; Horas Hombre | 2827.2h | 55 d | m3 |
| 66 | 1.3.3.1.2.2.4 | ENROCADO - TALUD | 68d | 2022-12-10 | 2023-02-15 | 65SS+15d | 34d | 0d | Enrocado; Horas Hombre | 3308.16h | 68 d | m3 |
| 67 | 1.3.3.1.2.2.5 | RELLENO CON MATERIAL PROPIO - UÑA | 41d | 2023-01-19 | 2023-02-28 | 66SS+40d | 88d | 0d | Rellenos dique [958700%]; Horas Hombre | 815.87h | 41 d | m3 |
| 68 | 1.3.3.1.2.2.6 | RELLENO CON MATERIAL AFIRMADO - CORONA | 41d | 2023-01-19 | 2023-02-28 | 67SS | 88d |  | Rellenos dique [546100%]; Horas Hombre | 725.15h | 41 d | m3 |
| 69 | 1.3.3.1.3 | **DIPR-17 MD (13+520 - 9+100) L=4.4km** | 138d | 2022-11-25 | 2023-04-11 |  | 46d |  |  | 36486h | 138 d |  |
| 70 | 1.3.3.1.3.1 | **EXCAVACIONES** | 75d | 2022-11-25 | 2023-02-07 |  | 109d |  |  | 14165.4h | 75 d |  |
| 71 | 1.3.3.1.3.1.1 | LIMPIEZA Y DESBROCE | 20d | 2022-11-25 | 2022-12-14 | 54 | 137d | 0d | Excavaciones; Horas Hombre | 448.9h | 20 d | Ha |
| 72 | 1.3.3.1.3.1.2 | EXCAVACION EN MATERIAL SUELTO | 27d | 2022-12-15 | 2023-01-10 | 71 | 137d |  | Excavaciones [536000%]; Horas Hombre | 367.21h | 27 d | m3 |
| 73 | 1.3.3.1.3.1.3 | EXCAVACION EN ROCA SUELTA | 47d | 2022-12-23 | 2023-02-07 | 57 | 100d | 0d | Excavaciones [28500%]; Horas Hombre | 164.14h | 47 d | m3 |
| 74 | 1.3.3.1.3.1.4 | EXCAVACION EN ROCA FIJA | 47d | 2022-12-23 | 2023-02-07 | 73SS | 100d | 0d | Excavaciones [8213%]; Horas Hombre | 94.44h | 47 d | m3 |
| 75 | 1.3.3.1.3.1.5 | EXCAVACION DE UÑA CON NIVEL FREATICO | 47d | 2022-12-23 | 2023-02-07 | 74SS | 100d | 0d | Excavaciones; Horas Hombre | 3363.11h | 47 d | m3 |
| 76 | 1.3.3.1.3.1.6 | MEJORAMIENTO DE SUELO DE FUNDACION | 47d | 2022-12-23 | 2023-02-07 | 75SS | 109d | 0d | Horas Hombre | 1264.16h | 47 d | m3 |
| 77 | 1.3.3.1.3.1.7 | PERFILADO DE TALUD + FUNDACION | 47d | 2022-12-23 | 2023-02-07 | 76SS | 109d | 0d | Horas Hombre | 6139.48h | 47 d | m2 |
| 78 | 1.3.3.1.3.1.8 | DESCOLMATACION DEL CAUCE | 47d | 2022-12-23 | 2023-02-07 | 77SS | 109d | 0d | Horas Hombre | 1610.31h | 47 d | m3 |
| 79 | 1.3.3.1.3.1.9 | CONFORMACION DE DME/DMO | 47d | 2022-12-23 | 2023-02-07 | 78SS | 109d |  | Horas Hombre | 713.65h | 47 d | m3 |
| 80 | 1.3.3.1.3.2 | **RELLENOS EN DIQUE** | 103d | 2022-12-30 | 2023-04-11 |  | 46d |  |  | 22320.6h | 103 d |  |
| 81 | 1.3.3.1.3.2.1 | CONFORMACION Y COMPACTACION DEL DIQUE | 47d | 2022-12-30 | 2023-02-14 | 75SS+7d | 100d | 0d | Rellenos dique; Horas Hombre | 3216.81h | 47 d | m3 |
| 82 | 1.3.3.1.3.2.2 | TRATAMIENTO DE TALUD CON GEOCELDAS | 47d | 2023-01-01 | 2023-02-16 | 81SS+2d | 100d | 0d | Horas Hombre | 4264.63h | 47 d | m2 |
| 83 | 1.3.3.1.3.2.3 | INSTALACION DE GEOTEXTIL | 47d | 2023-01-01 | 2023-02-16 | 82SS | 100d |  | Horas Hombre | 7242.74h | 47 d | m2 |
| 84 | 1.3.3.1.3.2.4 | ENROCADO - UÑA | 36d | 2023-01-19 | 2023-02-23 | 65 | 26d | 0d | Enrocado; Horas Hombre | 1955.36h | 36 d | m3 |
| 85 | 1.3.3.1.3.2.5 | ENROCADO - TALUD | 36d | 2023-02-24 | 2023-03-31 | 66, 84 | 26d | 0d | Enrocado; Horas Hombre | 3522.72h | 36 d | m3 |
| 86 | 1.3.3.1.3.2.6 | RELLENO CON MATERIAL PROPIO - UÑA | 42d | 2023-03-01 | 2023-04-11 | 85SS+5d | 26d | 0d | Rellenos dique [629300%]; Horas Hombre | 940.17h | 42 d | m3 |
| 87 | 1.3.3.1.3.2.7 | RELLENO CON MATERIAL AFIRMADO - CORONA | 42d | 2023-03-01 | 2023-04-11 | 86SS | 26d |  | Rellenos dique [306100%]; Horas Hombre | 1178.18h | 42 d | m3 |

| ID | WBS | Task | Duration | Start | Finish | Predecessors | Total slack | Free slack | Resources | Work | Días Calendario | Frente |
| --- | --- | --- | --- | --- | --- | --- | --- | --- | --- | --- | --- | --- |
| 88 | 1.3.3.2 | **Frente 02** | 138d | 2022-10-10 | 2023-02-24 |  | 38d |  |  | 34750.3h | 138 d |  |
| 89 | 1.3.3.2.1 | **DIPR-21 MI (23+800 - 21+600) L=2.06km** | 104d | 2022-10-10 | 2023-01-21 |  | 38d |  |  | 15162.9h | 104 d |  |
| 90 | 1.3.3.2.1.1 | **EXCAVACIONES** | 35d | 2022-10-10 | 2022-11-13 |  | 38d |  |  | 4933.48h | 35 d |  |
| 91 | 1.3.3.2.1.1.1 | EXCAVACION EN MATERIAL SUELTO | 25d | 2022-10-10 | 2022-11-03 | 29SS+30d | 38d | 0d | Excavaciones [939500%]; Horas Hombre | 643.64h | 25 d | m3 |
| 92 | 1.3.3.2.1.1.2 | EXCAVACION DE UÑA CON NIVEL FREATICO | 35d | 2022-10-10 | 2022-11-13 | 91SS | 38d | 0d | Excavaciones; Horas Hombre | 2560.21h | 35 d | m3 |
| 93 | 1.3.3.2.1.1.3 | PERFILADO DE TALUD EXISTENTE + FUNDACION | 35d | 2022-10-10 | 2022-11-13 | 92SS | 38d | 0d | Horas Hombre | 495.66h | 35 d | m2 |
| 94 | 1.3.3.2.1.1.4 | CONFORMACION DE DME/DMO | 35d | 2022-10-10 | 2022-11-13 | 93SS | 195d |  | Horas Hombre | 1233.97h | 35 d | m3 |
| 95 | 1.3.3.2.1.2 | **RELLENOS EN DIQUE** | 97d | 2022-10-17 | 2023-01-21 |  | 46d |  |  | 10229.4h | 97 d |  |
| 96 | 1.3.3.2.1.2.1 | CONFORMACION Y COMPACTACION DEL DIQUE | 35d | 2022-10-17 | 2022-11-20 | 92SS+7d | 186d | 0d | Rellenos dique [172000%]; Horas Hombre | 248.74h | 35 d | m3 |
| 97 | 1.3.3.2.1.2.2 | INSTALACION DE GEOTEXTIL | 35d | 2022-10-19 | 2022-11-22 | 96SS+2d | 186d |  | Horas Hombre | 4515.9h | 35 d | m2 |
| 98 | 1.3.3.2.1.2.3 | ENROCADO - UÑA | 34d | 2022-10-25 | 2022-11-27 | 93SS+15d | 38d | 0d | Enrocado; Horas Hombre | 1831.2h | 34 d | m3 |
| 99 | 1.3.3.2.1.2.4 | ENROCADO - TALUD | 47d | 2022-11-28 | 2023-01-13 | 98 | 38d | 0d | Enrocado [956800%]; Horas Hombre | 2296.32h | 47 d | m3 |
| 100 | 1.3.3.2.1.2.5 | RELLENO CON MATERIAL PROPIO - UÑA | 25d | 2022-12-28 | 2023-01-21 | 99SS+30d | 126d | 0d | Rellenos dique [393200%]; Horas Hombre | 587.44h | 25 d | m3 |
| 101 | 1.3.3.2.1.2.6 | RELLENO CON MATERIAL AFIRMADO - CORONA | 25d | 2022-12-28 | 2023-01-21 | 100SS | 126d |  | Rellenos dique [194800%]; Horas Hombre | 749.79h | 25 d | m3 |
| 102 | 1.3.3.2.2 | **DIPR-19 MI (20+300 - 19+780) L=0.55km** | 46d | 2022-11-04 | 2022-12-19 |  | 102d |  |  | 4274.32h | 46 d |  |
| 103 | 1.3.3.2.2.1 | **EXCAVACIONES** | 22d | 2022-11-04 | 2022-11-25 |  | 102d |  |  | 1609.72h | 22 d |  |
| 104 | 1.3.3.2.2.1.1 | EXCAVACION EN MATERIAL SUELTO | 11d | 2022-11-04 | 2022-11-14 | 91 | 138d | 0d | Excavaciones [221400%]; Horas Hombre | 151.68h | 11 d | m3 |
| 105 | 1.3.3.2.2.1.2 | EXCAVACION DE UÑA CON NIVEL FREATICO | 12d | 2022-11-14 | 2022-11-25 | 93 | 92d | 0d | Excavaciones [598500%]; Horas Hombre | 682.29h | 12 d | m3 |
| 106 | 1.3.3.2.2.1.3 | PERFILADO DE TALUD EXISTENTE + FUNDACION | 12d | 2022-11-14 | 2022-11-25 | 105SS | 92d | 0d | Horas Hombre | 504.24h | 12 d | m2 |
| 107 | 1.3.3.2.2.1.4 | CONFORMACION DE DME/DMO | 12d | 2022-11-14 | 2022-11-25 | 106SS | 183d |  | Horas Hombre | 271.51h | 12 d | m3 |
| 108 | 1.3.3.2.2.2 | **RELLENOS EN DIQUE** | 33d | 2022-11-17 | 2022-12-19 |  | 101d |  |  | 2664.6h | 33 d |  |
| 109 | 1.3.3.2.2.2.1 | CONFORMACION Y COMPACTACION DEL DIQUE | 15d | 2022-11-17 | 2022-12-01 | 105SS+3d | 175d | 0d | Rellenos dique [132100%]; Horas Hombre | 191.04h | 15 d | m3 |
| 110 | 1.3.3.2.2.2.2 | INSTALACION DE GEOTEXTIL | 15d | 2022-11-19 | 2022-12-03 | 109SS+2d | 175d |  | Horas Hombre | 1114.23h | 15 d | m2 |
| 111 | 1.3.3.2.2.2.3 | ENROCADO - UÑA | 10d | 2022-11-26 | 2022-12-05 | 106 | 92d | 0d | Enrocado [303600%]; Horas Hombre | 485.76h | 10 d | m3 |
| 112 | 1.3.3.2.2.2.4 | ENROCADO - TALUD | 12d | 2022-12-06 | 2022-12-17 | 111 | 92d | 0d | Enrocado [209000%]; Horas Hombre | 501.6h | 12 d | m3 |
| 113 | 1.3.3.2.2.2.5 | RELLENO CON MATERIAL PROPIO - UÑA | 8d | 2022-12-12 | 2022-12-19 | 112SS+6d | 159d | 0d | Rellenos dique [111400%]; Horas Hombre | 166.43h | 8 d | m3 |
| 114 | 1.3.3.2.2.2.6 | RELLENO CON MATERIAL AFIRMADO - CORONA | 8d | 2022-12-12 | 2022-12-19 | 113SS | 159d |  | Rellenos dique [53400%]; Horas Hombre | 205.54h | 8 d | m3 |

| ID | WBS | Task | Duration | Start | Finish | Predecessors | Total slack | Free slack | Resources | Work | Días Calendario | Frente |
| --- | --- | --- | --- | --- | --- | --- | --- | --- | --- | --- | --- | --- |
| 115 | 1.3.3.2.3 | **DIPR-15 MD (8+100 - 6+000) L=2.02km** | 102d | 2022-11-15 | 2023-02-24 |  | 92d |  |  | 15313.1h | 102 d |  |
| 116 | 1.3.3.2.3.1 | **EXCAVACIONES** | 46d | 2022-11-15 | 2022-12-30 |  | 138d |  |  | 4412.06h | 46 d |  |
| 117 | 1.3.3.2.3.1.1 | EXCAVACION EN MATERIAL SUELTO | 16d | 2022-11-15 | 2022-11-30 | 104 | 138d | 0d | Excavaciones [699800%]; Horas Hombre | 479.54h | 16 d | m3 |
| 118 | 1.3.3.2.3.1.2 | EXCAVACION DE UÑA CON NIVEL FREATICO | 30d | 2022-12-01 | 2022-12-30 | 117 | 138d | 0d | Excavaciones; Horas Hombre | 2152.7h | 30 d | m3 |
| 119 | 1.3.3.2.3.1.3 | PERFILADO DE TALUD + FUNDACION | 30d | 2022-12-01 | 2022-12-30 | 118SS | 148d | 0d | Horas Hombre | 964.53h | 30 d | m2 |
| 120 | 1.3.3.2.3.1.4 | CONFORMACION DE DME/DMO | 30d | 2022-12-01 | 2022-12-30 | 119SS | 148d |  | Horas Hombre | 815.29h | 30 d | m3 |
| 121 | 1.3.3.2.3.2 | **RELLENOS EN DIQUE** | 81d | 2022-12-06 | 2023-02-24 |  | 92d |  |  | 10901.1h | 81 d |  |
| 122 | 1.3.3.2.3.2.1 | CONFORMACION Y COMPACTACION DEL DIQUE | 35d | 2022-12-06 | 2023-01-09 | 118SS+5d | 138d | 0d | Rellenos dique [522400%]; Horas Hombre | 755.57h | 35 d | m3 |
| 123 | 1.3.3.2.3.2.2 | INSTALACION DE GEOTEXTIL | 35d | 2022-12-06 | 2023-01-09 | 122SS | 138d |  | Horas Hombre | 4705.49h | 35 d | m2 |
| 124 | 1.3.3.2.3.2.3 | ENROCADO - UÑA | 24d | 2022-12-18 | 2023-01-10 | 112 | 92d | 0d | Enrocado [807000%]; Horas Hombre | 1291.41h | 24 d | m3 |
| 125 | 1.3.3.2.3.2.4 | ENROCADO - TALUD | 38d | 2023-01-11 | 2023-02-17 | 124 | 92d | 0d | Enrocado; Horas Hombre | 3044.23h | 38 d | m3 |
| 126 | 1.3.3.2.3.2.5 | RELLENO CON MATERIAL PROPIO - UÑA | 20d | 2023-02-05 | 2023-02-24 | 125SS+25d | 92d | 0d | Rellenos dique [334500%]; Horas Hombre | 499.7h | 20 d | m3 |
| 127 | 1.3.3.2.3.2.6 | RELLENO CON MATERIAL AFIRMADO - CORONA | 20d | 2023-02-05 | 2023-02-24 | 126SS | 92d |  | Rellenos dique [157100%]; Horas Hombre | 604.68h | 20 d | m3 |
| 128 | 1.3.3.3 | **Frente 03** | 220d | 2022-09-30 | 2023-05-07 |  | 0d |  |  | 117634h | 220 d |  |
| 129 | 1.3.3.3.1 | **DIPR-16-MI (19+560 - 6+000) L=14.02km** | 220d | 2022-09-30 | 2023-05-07 |  | 0d |  |  | 117634h | 220 d |  |
| 130 | 1.3.3.3.1.1 | **EXCAVACIONES** | 123d | 2022-09-30 | 2023-01-30 |  | 0d |  |  | 36910h | 123 d |  |
| 131 | 1.3.3.3.1.1.1 | LIMPIEZA Y DESBROCE | 86d | 2022-09-30 | 2022-12-24 | 29 | 0d |  | Excavaciones; Horas Hombre | 911.2h | 86 d | Ha |
| 132 | 1.3.3.3.1.1.2 | EXCAVACION EN MATERIAL SUELTO | 86d | 2022-09-30 | 2022-12-24 | 131SS | 0d |  | Excavaciones; Horas Hombre | 2146.74h | 86 d | m3 |
| 133 | 1.3.3.3.1.1.3 | EXCAVACION EN ROCA SUELTA | 78d | 2022-11-14 | 2023-01-30 | 132SS+45d | 0d |  | Excavaciones [57800%]; Horas Hombre | 333.1h | 78 d | m3 |
| 134 | 1.3.3.3.1.1.4 | EXCAVACION EN ROCA FIJA | 78d | 2022-11-14 | 2023-01-30 | 133SS | 0d |  | Excavaciones [16657%]; Horas Hombre | 191.54h | 78 d | m3 |
| 135 | 1.3.3.3.1.1.5 | EXCAVACION DE UÑA CON NIVEL FREATICO | 78d | 2022-11-14 | 2023-01-30 | 134SS | 0d |  | Excavaciones; Horas Hombre | 11447.5h | 78 d | m3 |
| 136 | 1.3.3.3.1.1.6 | MEJORAMIENTO DE SUELO DE FUNDACION | 78d | 2022-11-14 | 2023-01-30 | 135SS | 0d |  | Horas Hombre | 4303.02h | 78 d | m3 |
| 137 | 1.3.3.3.1.1.7 | PERFILADO DE TALUD + FUNDACION | 78d | 2022-11-14 | 2023-01-30 | 136SS | 0d |  | Horas Hombre | 7653.87h | 78 d | m2 |
| 138 | 1.3.3.3.1.1.8 | DESCOLMATACION DEL CAUCE | 78d | 2022-11-14 | 2023-01-30 | 137SS | 0d |  | Horas Hombre | 6501.17h | 78 d | m3 |
| 139 | 1.3.3.3.1.1.9 | CONFORMACION DE DME/DMO | 78d | 2022-11-14 | 2023-01-30 | 138SS | 0d |  | Horas Hombre | 3421.8h | 78 d | m3 |

| ID | WBS | Task | Type | Duration | Start | Finish | Predecessors | Total slack | Free slack | Resources | Work | Días Calendario | Frente |
| --- | --- | --- | --- | --- | --- | --- | --- | --- | --- | --- | --- | --- | --- |
| 140 | 1.3.3.3.1.2 | **RELLENOS EN DIQUE** |  | 170d | 2022-11-19 | 2023-05-07 |  | 0d |  |  | 80724h | 170 d |  |
| 141 | 1.3.3.3.1.2.1 | CONFORMACION Y COMPACTACION DEL DIQUE |  | 78d | 2022-11-19 | 2023-02-04 | 139SS+5d | 0d |  | Rellenos dique; Horas Hombre | 12987h | 78 d | m3 |
| 142 | 1.3.3.3.1.2.2 | TRATAMIENTO DE TALUD CON GEOCELDAS |  | 78d | 2022-11-21 | 2023-02-06 | 141SS+2d | 0d |  | Horas Hombre | 15160.1h | 78 d | m2 |
| 143 | 1.3.3.3.1.2.3 | INSTALACION DE GEOTEXTIL |  | 78d | 2022-11-23 | 2023-02-08 | 142SS+2d | 0d |  | Horas Hombre | 23523.3h | 78 d | m2 |
| 144 | 1.3.3.3.1.2.4 | ENROCADO - UÑA |  | 80d | 2022-12-09 | 2023-02-26 | 139SS+25d, 143SS+16d | 0d |  | Enrocado; Horas Hombre | 7479.36h | 80 d | m3 |
| 145 | 1.3.3.3.1.2.5 | ENROCADO - TALUD |  | 115d | 2022-12-25 | 2023-04-18 | 132, 144SS+16d | 0d |  | Enrocado; Horas Hombre | 15911.5h | 115 d | m3 |
| 146 | 1.3.3.3.1.2.6 | RELLENO CON MATERIAL PROPIO - UÑA |  | 58d | 2023-03-11 | 2023-05-07 | 145SS+76d | 0d |  | Rellenos dique; Horas Hombre | 2785.71h | 58 d | m3 |
| 147 | 1.3.3.3.1.2.7 | RELLENO CON MATERIAL AFIRMADO - CORONA |  | 58d | 2023-03-11 | 2023-05-07 | 146SS | 0d |  | Rellenos dique [747500%]; Horas Hombre | 2877h | 58 d | m3 |
| 148 | 1.3.4 | **TRANSPORTES DE MATERIAL** |  | 220d | 2022-09-30 | 2023-05-07 |  | 20d |  |  | 55638.1h | 220 d |  |
| 149 | 1.3.4.1 | CARGUIO Y ACARREO DE MATERIAL PROPIO P/DIQUE D≤1km |  | 220d | 2022-09-30 | 2023-05-07 | 35SS | 20d | 0d | Horas Hombre | 4462.29h | 220 d | m3-km |
| 150 | 1.3.4.2 | CARGUIO Y ACARREO DE MATERIAL DE PRESTAMO P/DIQUE D≤1km |  | 220d | 2022-09-30 | 2023-05-07 | 149SS | 20d | 0d | Horas Hombre | 493.2h | 220 d | m3-km |
| 151 | 1.3.4.3 | CARGUIO Y TRANSPORTE DE MATERIAL AFIRMADO D≤1KM |  | 220d | 2022-09-30 | 2023-05-07 | 150SS | 20d | 0d | Horas Hombre | 660.35h | 220 d | m3-km |
| 152 | 1.3.4.4 | ACARREO DE MATERIAL PROPIO P/DIQUE D>1km |  | 220d | 2022-09-30 | 2023-05-07 | 151SS | 20d | 0d | Horas Hombre | 2332.18h | 220 d | m3-km |
| 153 | 1.3.4.5 | ACARREO DE MATERIAL DE PRESTAMO P/DIQUE D>1Km |  | 220d | 2022-09-30 | 2023-05-07 | 152SS | 20d | 0d | Horas Hombre | 265.11h | 220 d | m3-km |
| 154 | 1.3.4.6 | TRANSPORTE DE MATERIAL AFIRMADO D>1KM |  | 220d | 2022-09-30 | 2023-05-07 | 153SS | 20d | 0d | Horas Hombre | 888.25h | 220 d | m3-km |
| 155 | 1.3.4.7 | CARGUIO Y TRANSPORTE DE MATERIAL EXCEDENTE CON EQUIPO D≤ 1km |  | 220d | 2022-09-30 | 2023-05-07 | 154SS | 20d | 0d | Horas Hombre | 9625.95h | 220 d | m3-km |
| 156 | 1.3.4.8 | TRANSPORTE DE MATERIAL EXCEDENTE CON EQUIPO D> 1km |  | 220d | 2022-09-30 | 2023-05-07 | 155SS | 20d | 0d | Horas Hombre | 6927.52h | 220 d | m3-km |
| 157 | 1.3.4.9 | TRANSPORTE DE MATERIAL INTERNO PARA ACOPIO ≤1km (INCLUYE CARGUÍO) |  | 220d | 2022-09-30 | 2023-05-07 | 156SS | 20d | 0d | Horas Hombre | 114.26h | 220 d | m3-km |
| 158 | 1.3.4.10 | CARGUIO Y TRANSPORTE DE ROCA SELECCIONADA D≤1km |  | 220d | 2022-09-30 | 2023-05-07 | 157SS | 20d | 0d | Horas Hombre | 19846h | 220 d | m3-km |
| 159 | 1.3.4.11 | TRANSPORTE DE ROCA SELECIONADA D >1km |  | 220d | 2022-09-30 | 2023-05-07 | 158SS | 20d |  | Horas Hombre | 10023h | 220 d | m3-km |
| 160 | 1.3.5 | **COMPONENTE DE INTERFERENCIAS** |  | 96d | 2023-01-14 | 2023-04-19 |  | 38d |  |  | 40759.7h | 96 d |  |
| 161 | 1.3.5.1 | CONSTRUCCIÓN DE CRUCE VIAL CON BADÉN SIN REVESTIMIENTO |  | 7d | 2023-01-14 | 2023-01-20 | 99 | 38d | 0d | Horas Hombre | 510.46h | 7 d | und |
| 162 | 1.3.5.2 | REUBICACIÓN DE CANAL REVESTIDO |  | 18d | 2023-01-21 | 2023-02-07 | 161 | 38d | 0d | Horas Hombre | 16134h | 18 d | ml |
| 163 | 1.3.5.3 | REEMPLAZO DE BOCATOMA |  | 40d | 2023-02-08 | 2023-03-19 | 162 | 38d | 0d | Horas Hombre | 24115.3h | 40 d | und |
| 164 | 1.3.5.4 | REUBICACION DE POSTE DE ENERGIA |  | 6d | 2023-03-20 | 2023-03-25 | 163 | 38d | 0d |  |  | 6 d | und |
| 165 | 1.3.5.5 | REUBICACIÓN DE POSTE DE TELEFONÍA | milestone | 0d | 2023-03-25 | 2023-03-25 | 164 | 38d | 0d |  |  | 0 d | und |
| 166 | 1.3.5.6 | REUBICACIÓN DE POSTE DE DATOS | milestone | 0d | 2023-03-25 | 2023-03-25 | 165 | 38d | 0d |  |  | 0 d | und |
| 167 | 1.3.5.7 | REUBICACION DE POZO SUPERFICIAL |  | 10d | 2023-03-26 | 2023-04-04 | 166 | 38d | 0d |  |  | 10 d | und |
| 168 | 1.3.5.8 | REUBICACION DE POZO PROFUNDO |  | 15d | 2023-04-05 | 2023-04-19 | 167 | 38d | 0d |  |  | 15 d | und |
| 169 | 1.3.5.9 | REUBICACIÓN DE TUBERÍA AGUA | milestone | 0d | 2023-04-19 | 2023-04-19 | 168 | 38d |  |  |  | 0 d | und |

| ID | WBS | Task | Duration | Start | Finish | Predecessors | Total slack | Días Calendario |
| --- | --- | --- | --- | --- | --- | --- | --- | --- |
| 170 | 1.4 | **ACTIVIDADES POST CONSTRUCCION** | 20d | 2023-05-08 | 2023-05-27 |  | 0d | 20 d |
| 171 | 1.4.1 | CIERRE DE PROYECTO, DESMOVILIZACION DE PERSONAL Y EQUIPOS | 20d | 2023-05-08 | 2023-05-27 | 147, 87 | 0d | 20 d |
